# 井冈山学院数理大楼

Schedule from MS Project, 2004-11-15 to 2006-02-14, status date 2004-04-06.

## Calendars

- 标准: Mon-Fri 08:00-12:00, 13:00-17:00; Sat-Sun off. Exceptions (off unless hours are given): 2004-11-05 to 2004-11-30 08:00-12:00, 13:00-17:00, 2004-12-03 to 2004-12-28 08:00-12:00, 13:00-17:00, 2005-01-01 to 2005-01-31 08:00-12:00, 13:00-17:00, 2005-02-03 to 2005-02-16, 2005-02-17 to 2005-02-28 08:00-12:00, 13:00-17:00, 2005-03-05 to 2005-03-28 08:00-12:00, 13:00-17:00, 2005-04-02 to 2005-06-28 08:00-12:00, 13:00-17:00, 2005-07-01 to 2005-07-31 08:00-12:00, 13:00-17:00, 2005-08-05 to 2005-08-31 08:00-12:00, 13:00-17:00, 2005-09-03 to 2005-10-31 08:00-12:00, 13:00-17:00, 2005-11-05 to 2005-11-30 08:00-12:00, 13:00-17:00, 2005-12-03 to 2006-01-24 08:00-12:00, 13:00-17:00, 2006-01-25 to 2006-02-06, 2006-02-07 to 2006-03-28 08:00-12:00, 13:00-17:00.

## Schedule

| ID | WBS | Task | Duration | Start | Finish | Predecessors | Total slack | Free slack | Constraint | Text3 |
| --- | --- | --- | --- | --- | --- | --- | --- | --- | --- | --- |
| 1 | 1 | 准备工作 | 10d | 2004-11-15 | 2004-11-24 |  | 0d |  | start no earlier than 2004-11-15 |  |
| 2 | 2 | 测量放线 | 5d | 2004-11-25 | 2004-11-29 | 1 | 0d |  |  |  |
| 3 | 3 | **基础工程** | 99d | 2004-11-30 | 2005-03-22 |  | 0d |  |  |  |
| 4 | 3.1 | 人工挖孔桩 | 40d | 2004-11-30 | 2005-01-08 | 2 | 0d |  |  |  |
| 5 | 3.2 | 挖基坑／槽 | 8d | 2005-01-09 | 2005-01-16 | 4 | 7d | 0d |  |  |
| 6 | 3.3 | 桩基测试 | 15d | 2005-01-09 | 2005-01-23 | 4 | 0d |  |  |  |
| 7 | 3.4 | 桩承台、基础梁、挡土墙 | 18d | 2005-01-24 | 2005-02-24 | 6, 5 | 0d |  |  |  |
| 8 | 3.5 | 砖基础 | 8d | 2005-02-25 | 2005-03-04 | 7 | 0d |  |  |  |
| 9 | 3.6 | 回填土 | 5d | 2005-03-05 | 2005-03-09 | 8 | 0d |  |  |  |
| 10 | 3.7 | 人工挖孔桩 | 38d | 2004-12-05 | 2005-01-11 | 2 | 21d | 0d | start no earlier than 2004-12-05 | II |
| 11 | 3.8 | 挖基坑／槽 | 8d | 2005-01-12 | 2005-01-19 | 10 | 28d | 7d |  | II |
| 12 | 3.9 | 桩基测试 | 15d | 2005-01-12 | 2005-01-26 | 10 | 21d | 0d |  | II |
| 13 | 3.10 | 桩承台、基础梁 | 12d | 2005-01-27 | 2005-02-21 | 12, 11 | 21d | 0d |  | II |
| 14 | 3.11 | 砖基础 | 8d | 2005-02-22 | 2005-03-01 | 13 | 21d | 0d |  | II |
| 15 | 3.12 | 回填土 | 5d | 2005-03-02 | 2005-03-06 | 14 | 21d | 19d |  | II |
| 16 | 3.13 | 人工挖孔桩 | 45d | 2004-12-11 | 2005-01-24 | 2 | 19d | 0d | start no earlier than 2004-12-11 | III |
| 17 | 3.14 | 挖基坑／槽 | 10d | 2005-01-25 | 2005-02-17 | 16 | 24d | 5d |  | III |
| 18 | 3.15 | 桩基测试 | 15d | 2005-01-25 | 2005-02-22 | 16 | 19d | 0d |  | III |
| 19 | 3.16 | 桩承台、基础梁 | 15d | 2005-02-23 | 2005-03-09 | 18, 17 | 19d | 0d |  | III |
| 20 | 3.17 | 砖基础 | 8d | 2005-03-10 | 2005-03-17 | 19 | 19d | 0d |  | III |
| 21 | 3.18 | 回填土 | 5d | 2005-03-18 | 2005-03-22 | 20 | 19d | 17d |  | III |
| 22 | 4 | **主体工程** | 218d | 2005-03-10 | 2005-10-13 |  | 0d |  |  |  |
| 23 | 4.1 | -7.8m框架柱 | 8d | 2005-03-10 | 2005-03-17 | 9 | 0d |  |  |  |
| 24 | 4.2 | -7.8m框架梁板 | 8d | 2005-03-18 | 2005-03-25 | 23 | 0d |  |  |  |
| 25 | 4.3 | -3.9m框架柱 | 8d | 2005-03-26 | 2005-04-02 | 24 | 0d |  |  |  |
| 26 | 4.4 | -3.9m框架梁板 | 8d | 2005-04-03 | 2005-04-10 | 25 | 0d |  |  |  |
| 27 | 4.5 | 一层框架柱 | 8d | 2005-04-11 | 2005-04-18 | 26 | 0d |  |  |  |
| 28 | 4.6 | 一层框架梁板 | 8d | 2005-04-19 | 2005-04-26 | 27 | 0d |  |  |  |
| 29 | 4.7 | 二层框架柱 | 8d | 2005-04-27 | 2005-05-04 | 28 | 0d |  |  |  |
| 30 | 4.8 | 二层框架梁板 | 8d | 2005-05-05 | 2005-05-12 | 29 | 0d |  |  |  |
| 31 | 4.9 | 三层框架柱 | 8d | 2005-05-13 | 2005-05-20 | 30 | 0d |  |  |  |
| 32 | 4.10 | 三层框架梁板 | 8d | 2005-05-21 | 2005-05-28 | 31 | 0d |  |  |  |
| 33 | 4.11 | 四层框架柱 | 8d | 2005-05-29 | 2005-06-05 | 32 | 39d | 0d |  |  |
| 34 | 4.12 | 四层框架梁板 | 8d | 2005-06-06 | 2005-06-13 | 33 | 39d | 0d |  |  |
| 35 | 4.13 | 五层框架柱 | 8d | 2005-06-14 | 2005-06-21 | 34 | 39d | 0d |  |  |
| 36 | 4.14 | 五层框架梁板 | 8d | 2005-06-22 | 2005-06-29 | 35 | 39d | 0d |  |  |
| 37 | 4.15 | 屋面构筑物 | 32d | 2005-06-30 | 2005-07-31 | 36 | 39d | 0d |  |  |
| 38 | 4.16 | 内外填充墙砌体 | 48d | 2005-05-29 | 2005-07-15 | 32 | 0d |  | finish no earlier than 2003-07-05 |  |
| 39 | 4.17 | 构造柱、过梁 | 48d | 2005-05-29 | 2005-07-15 | 32 | 0d |  | start no earlier than 2003-05-29 |  |
| 40 | 4.18 | 连廊栏板 | 15d | 2005-06-30 | 2005-07-14 | 36 | 56d | 17d |  |  |
| 41 | 4.19 | -3.9m框架柱 | 7d | 2005-03-26 | 2005-04-01 | 15, 24 | 2d | 0d |  | II |
| 42 | 4.20 | -3.9m框架梁板 | 7d | 2005-04-02 | 2005-04-08 | 41 | 2d | 0d |  | II |
| 43 | 4.21 | 一层框架柱 | 7d | 2005-04-09 | 2005-04-15 | 42 | 13d | 0d |  | II |
| 44 | 4.22 | 一层框架梁板 | 7d | 2005-04-16 | 2005-04-22 | 43 | 13d | 0d |  | II |
| 45 | 4.23 | 二层框架柱 | 7d | 2005-04-23 | 2005-04-29 | 44 | 13d | 0d |  | II |
| 46 | 4.24 | 二层框架梁板 | 7d | 2005-04-30 | 2005-05-06 | 45 | 13d | 0d |  | II |
| 47 | 4.25 | 三层框架柱 | 7d | 2005-05-07 | 2005-05-13 | 46 | 13d | 0d |  | II |
| 48 | 4.26 | 三层框架梁板 | 7d | 2005-05-14 | 2005-05-20 | 47 | 13d | 0d |  | II |
| 49 | 4.27 | 四层框架柱 | 7d | 2005-05-21 | 2005-05-27 | 48 | 38d | 0d |  | II |
| 50 | 4.28 | 四层框架梁板 | 7d | 2005-05-28 | 2005-06-03 | 49 | 38d | 0d |  | II |
| 51 | 4.29 | 五层框架柱 | 7d | 2005-06-04 | 2005-06-10 | 50 | 38d | 0d |  | II |
| 52 | 4.30 | 五层框架梁板 | 7d | 2005-06-11 | 2005-06-17 | 51 | 38d | 0d |  | II |
| 53 | 4.31 | 屋面构筑物 | 35d | 2005-06-18 | 2005-07-22 | 52 | 38d | 0d |  | II |
| 54 | 4.32 | 内外填充墙砌体 | 42d | 2005-05-21 | 2005-07-01 | 48 | 13d | 0d |  | II |
| 55 | 4.33 | 构造柱、过梁 | 42d | 2005-05-21 | 2005-07-01 | 48 | 13d | 0d |  | II |
| 56 | 4.34 | 连廊栏板 | 20d | 2005-06-18 | 2005-07-07 | 52 | 63d | 24d |  | II |
| 57 | 4.35 | 一层框架柱 | 8d | 2005-04-09 | 2005-04-16 | 21, 42 | 2d | 0d |  | III |
| 58 | 4.36 | 一层框架梁板 | 8d | 2005-04-17 | 2005-04-24 | 57 | 2d | 0d |  | III |
| 59 | 4.37 | 二层框架柱 | 8d | 2005-04-25 | 2005-05-02 | 58 | 2d | 0d |  | III |
| 60 | 4.38 | 二层框架梁板 | 8d | 2005-05-03 | 2005-05-10 | 59 | 2d | 0d |  | III |
| 61 | 4.39 | 三层框架柱 | 8d | 2005-05-11 | 2005-05-18 | 60 | 2d | 0d |  | III |
| 62 | 4.40 | 三层框架梁板 | 8d | 2005-05-19 | 2005-05-26 | 61 | 2d | 0d | finish no earlier than 2003-07-05 | III |
| 63 | 4.41 | 四层框架柱 | 8d | 2005-05-27 | 2005-06-03 | 62 | 2d | 0d | start no earlier than 2003-05-29 | III |
| 64 | 4.42 | 四层框架梁板 | 8d | 2005-06-04 | 2005-06-11 | 63 | 2d | 0d |  | III |
| 65 | 4.43 | 五层框架柱 | 8d | 2005-06-12 | 2005-06-19 | 64 | 2d | 0d |  | III |
| 66 | 4.44 | 五层框架梁板 | 8d | 2005-06-20 | 2005-06-27 | 65 | 2d | 0d |  | III |
| 67 | 4.45 | 六层框架柱 | 8d | 2005-06-28 | 2005-07-05 | 66 | 2d | 0d |  | III |
| 68 | 4.46 | 六层框架梁板 | 8d | 2005-07-06 | 2005-07-13 | 67 | 2d | 0d |  | III |
| 69 | 4.47 | 屋面构筑物 | 35d | 2005-07-14 | 2005-08-17 | 68 | 2d | 0d |  | III |
| 70 | 4.48 | 内外填充墙砌体 | 20d | 2005-06-12 | 2005-07-01 | 64 | 5d | 0d |  | III |

| ID | WBS | Task | Duration | Start | Finish | Predecessors | Total slack | Free slack | Constraint | Text3 |
| --- | --- | --- | --- | --- | --- | --- | --- | --- | --- | --- |
| 71 | 4.49 | 构造柱、过梁 | 20d | 2005-06-12 | 2005-07-01 | 64 | 5d | 0d |  | III |
| 72 | 4.50 | 连廊栏板 | 20d | 2005-07-14 | 2005-08-02 | 68 | 17d | 15d |  | III |
| 73 | 4.51 | 脚手架工程 | 210d | 2005-03-18 | 2005-10-13 | 23 | 41d |  |  |  |
| 74 | 4.52 | 屋面找平层 | 8d | 2005-08-18 | 2005-08-25 | 69, 53, 37 | 109d | 0d |  |  |
| 75 | 4.53 | 屋面保温隔热层 | 6d | 2005-08-26 | 2005-08-31 | 74 | 109d | 0d |  |  |
| 76 | 4.54 | 屋面防水层 | 12d | 2005-09-01 | 2005-09-12 | 75 | 109d | 0d |  |  |
| 77 | 4.55 | 屋面保护层 | 8d | 2005-09-13 | 2005-09-20 | 76 | 109d |  |  |  |
| 78 | 5 | **装饰工程** | 190d | 2005-07-02 | 2006-01-07 |  | 0d |  |  |  |
| 79 | 5.1 | 外墙面粉刷 | 36d | 2005-08-01 | 2005-09-05 | 40, 37, 56 | 39d | 0d |  |  |
| 80 | 5.2 | 外墙面砖、涂料 | 22d | 2005-09-06 | 2005-09-27 | 79 | 39d | 0d |  |  |
| 81 | 5.3 | 构件装饰 | 18d | 2005-09-28 | 2005-10-15 | 80 | 39d |  |  |  |
| 82 | 5.4 | 内墙/天棚粉刷 | 48d | 2005-07-16 | 2005-09-01 | 38, 39 | 0d |  |  |  |
| 83 | 5.5 | 楼地面面层 | 30d | 2005-09-02 | 2005-10-01 | 82 | 0d |  |  |  |
| 84 | 5.6 | 门窗安装 | 18d | 2005-10-02 | 2005-10-19 | 83 | 0d |  |  |  |
| 85 | 5.7 | 楼梯踏步扶手 | 38d | 2005-10-02 | 2005-11-08 | 83 | 15d |  |  |  |
| 86 | 5.8 | 油漆 | 35d | 2005-10-20 | 2005-11-23 | 84 | 0d |  |  |  |
| 87 | 5.9 | 室外工程 | 45d | 2005-11-24 | 2006-01-07 | 81, 85, 73, 86 | 0d |  |  |  |
| 88 | 5.10 | 外墙面粉刷 | 42d | 2005-07-23 | 2005-09-02 | 53 | 38d | 0d |  | II |
| 89 | 5.11 | 外墙面砖、涂料 | 36d | 2005-09-03 | 2005-10-08 | 88 | 38d | 0d |  | II |
| 90 | 5.12 | 构件装饰 | 18d | 2005-10-09 | 2005-10-26 | 89 | 38d | 25d |  | II |
| 91 | 5.13 | 内墙/天棚粉刷 | 48d | 2005-07-02 | 2005-08-18 | 54, 55 | 13d | 0d |  | II |
| 92 | 5.14 | 楼地面面层 | 32d | 2005-08-19 | 2005-09-19 | 91 | 13d | 0d |  | II |
| 93 | 5.15 | 门窗安装 | 24d | 2005-09-20 | 2005-10-13 | 92 | 13d | 0d |  | II |
| 94 | 5.16 | 楼梯踏步扶手 | 38d | 2005-09-20 | 2005-10-27 | 92 | 37d | 24d |  | II |
| 95 | 5.17 | 油漆 | 38d | 2005-10-14 | 2005-11-20 | 93 | 13d | 0d |  | II |
| 96 | 5.18 | 室外工程 | 35d | 2005-11-21 | 2005-12-25 | 90, 94, 95 | 13d |  | finish no earlier than 2004-01-28 | II |
| 97 | 5.19 | 外墙面粉刷 | 42d | 2005-08-18 | 2005-09-28 | 69, 72 | 2d | 0d |  | III |
| 98 | 5.20 | 外墙面砖、涂料 | 36d | 2005-09-29 | 2005-11-03 | 97 | 2d | 0d |  | III |
| 99 | 5.21 | 构件装饰 | 18d | 2005-11-04 | 2005-11-21 | 98 | 2d | 0d |  | III |
| 100 | 5.22 | 内墙/天棚粉刷 | 48d | 2005-07-02 | 2005-08-18 | 70, 71 | 5d | 0d |  | III |
| 101 | 5.23 | 楼地面面层 | 32d | 2005-08-19 | 2005-09-19 | 100 | 5d | 0d |  | III |
| 102 | 5.24 | 门窗安装 | 22d | 2005-09-20 | 2005-10-11 | 101 | 5d | 0d |  | III |
| 103 | 5.25 | 楼梯踏步扶手 | 42d | 2005-09-20 | 2005-10-31 | 101 | 23d | 21d |  | III |
| 104 | 5.26 | 油漆 | 38d | 2005-10-12 | 2005-11-18 | 102 | 5d | 3d |  | III |
| 105 | 5.27 | 室外工程 | 45d | 2005-11-22 | 2006-01-05 | 103, 99, 104 | 2d |  |  | III |

| ID | WBS | Task | Duration | Start | Finish | Predecessors | Total slack | Free slack | Constraint |
| --- | --- | --- | --- | --- | --- | --- | --- | --- | --- |
| 106 | 6 | **水电消防安装** | 317d | 2005-01-17 | 2005-12-13 |  | 25d |  |  |
| 107 | 6.1 | 水电管道预埋 | 168d | 2005-01-17 | 2005-07-17 | 5 | 97d | 0d | finish no earlier than 2003-09-30 |
| 108 | 6.2 | 水暖管道安装 | 35d | 2005-07-18 | 2005-08-21 | 107 | 97d | 6d | start no earlier than 2005-03-20 |
| 109 | 6.3 | 卫生洁具安装 | 42d | 2005-08-28 | 2005-10-08 | 108 | 91d |  | start no earlier than 2005-08-28 |
| 110 | 6.4 | 强弱电线穿管 | 30d | 2005-07-24 | 2005-08-22 | 107 | 93d | 68d | start no earlier than 2005-07-24 |
| 111 | 6.5 | 电气设备安装 | 45d | 2005-10-30 | 2005-12-13 | 110 | 25d |  | start no earlier than 2005-10-30 |
| 112 | 7 | 竣工扫尾 | 24d | 2006-01-08 | 2006-02-13 | 96, 111, 105, 104, 95, 87, 86, 109, 77 | 0d |  | start no earlier than 2005-05-15 |
| 113 | 8 | 竣工验收 | 1d | 2006-02-14 | 2006-02-14 | 112 | 0d |  |  |
